# HMG

Schedule from MS Project, 2021-04-05 to 2021-09-17.
PRAGOPROJEKT, a.s.

## Calendars

- Standardní: Mon-Fri 09:00-13:00, 14:00-18:00; Sat-Sun off. Exceptions (off unless hours are given): 2021-01-01 to 2021-12-31 09:00-13:00, 14:00-18:00 (práce).

## Schedule

| ID | WBS | Task | Type | Duration | Start | Finish | Predecessors | Total slack | Constraint | SO |
| --- | --- | --- | --- | --- | --- | --- | --- | --- | --- | --- |
| 1 | 1 | Zahájení stavby | milestone | 0d | 2021-04-05 | 2021-04-05 |  | 0d | start no earlier than 2021-04-05 |  |
| 2 | 2 | **Dopravní opatření v průběhu výstavby** |  | 165.75d | 2021-04-05 | 2021-09-17 |  | 0d |  | 180 |
| 3 | 2.1 | Etapa 1 (přeložky inženýrských sítí) |  | 3w | 2021-04-05 | 2021-04-25 | 1 | 0d |  |  |
| 4 | 2.2 | Etapa 2a (příprava na snesení konstrukce mostu) |  | 6h | 2021-04-26 | 2021-04-26 | 3 | 0d |  |  |
| 5 | 2.3 | Etapa 2b (snesení konstrukce mostu) |  | 14h | 2021-04-26 | 2021-04-28 | 4 | 0d |  |  |
| 6 | 2.4 | Etapa 2c (dokončení snášení konstrukce mostu) |  | 6h | 2021-04-28 | 2021-04-29 | 5 | 0d |  |  |
| 7 | 2.5 | Etapa 3 (realizace základů a opěr) |  | 8w | 2021-04-29 | 2021-06-24 | 6 | 0d |  |  |
| 8 | 2.6 | Etapa 4 (osazení nosníků) |  | 12h | 2021-06-24 | 2021-06-25 | 7 | 0d |  |  |
| 9 | 2.7 | Etapa 5a (zmonolitnění konstrukce) |  | 3w | 2021-06-25 | 2021-07-16 | 8 | 0d |  |  |
| 10 | 2.8 | Etapa 5b (dokončení mostu) |  | 9w | 2021-07-16 | 2021-09-17 | 9 | 0d |  |  |
| 11 | 3 | **Most ev.č. 101-075a přes D11 a přilehlá silnice** |  | 144.75d | 2021-04-26 | 2021-09-17 |  | 0d |  | 201 |
| 12 | 3.1 | Most ev.č. 101-075a přes D11 - snesení |  | 26h | 2021-04-26 | 2021-04-29 | 21 | 0d |  |  |
| 13 | 3.2 | Výstavba základů a opěr |  | 8w | 2021-04-29 | 2021-06-24 | 12 | 0d |  |  |
| 14 | 3.3 | Osazení nosníků |  | 12h | 2021-06-24 | 2021-06-25 | 13 | 0d |  |  |
| 15 | 3.4 | Betonáž desky, výstavba křídel, provedení říms, vozovky, vybavení mostu, zásyp |  | 12w | 2021-06-25 | 2021-09-17 | 14 | 0d |  |  |
| 16 | 4 | Přeložka vedení NN ČEZ Distribuce |  | 3w | 2021-04-05 | 2021-04-25 | 1 | 144.75d |  | 430 |
| 17 | 5 | **Úprava vedení VO na mostě** |  | 165.75d | 2021-04-05 | 2021-09-17 |  | 0d |  | 431 |
| 18 | 5.1 | Demontáž VO |  | 1w | 2021-04-05 | 2021-04-11 | 1 | 158.75d |  |  |
| 19 | 5.2 | Montáž VO |  | 2w | 2021-09-03 | 2021-09-17 | 15FF | 0d |  |  |
| 20 | 6 | Přeložka sdělovacích kabelů CETIN |  | 3w | 2021-04-05 | 2021-04-25 | 1 | 144.75d |  | 461 |
| 21 | 7 | Přeložka STL plynovodu |  | 3w | 2021-04-05 | 2021-04-25 | 1 | 0d |  | 501 |
| 22 | 8 | Zprovoznění stavby | milestone | 0d | 2021-09-17 | 2021-09-17 | 15FF | 0d |  |  |
